# CRONOGRAMA GENERAL

Schedule from MS Project, 2019-10-10 to 2020-03-08.
www.intercambiosvirtuales.org

## Calendars

- Estándar: Mon-Sun 08:00-13:00, 14:00-17:00.

## Schedule

| ID | WBS | Task | Duration | Start | Finish | Predecessors | Total slack | Free slack | Constraint | Text1 |
| --- | --- | --- | --- | --- | --- | --- | --- | --- | --- | --- |
| 2 | 1 | **"REHABILITACION DEL SERVICIO EDUCATIVO DE LA INSTITUCION EDUCATIVA N° 15143 DEL CENTRO POBLADO PEDREGAL CHICO DEL DISTRITO DE CATACAOS, PROVINCIA DE PIURA - PIURA** | 150d | 2019-10-10 | 2020-03-08 |  | 0d |  |  |  |
| 3 | 1.1 | **ESTRUCTURAS** | 122d | 2019-10-10 | 2020-02-09 |  | 0d |  |  | 01 |
| 4 | 1.1.1 | **OBRAS PROVISIONALES** | 2d | 2019-10-10 | 2019-10-12 |  | 3d | 0d |  | 01.01 |
| 5 | 1.1.1.1 | OBRAS PROVISIONALES | 2d | 2019-10-10 | 2019-10-12 |  | 3d | 0d |  | 01.01 |
| 6 | 1.1.2 | **TRABAJOS PRELIMINARES** | 120d | 2019-10-12 | 2020-02-09 | 4 | 28d |  |  | 01.02 |
| 7 | 1.1.2.1 | TRAZO Y REPLANTEO | 120d | 2019-10-12 | 2020-02-09 |  | 28d |  |  | 01.02.01 |
| 8 | 1.1.2.2 | DESMONTAJES | 3d | 2019-10-12 | 2019-10-15 |  | 145d |  |  | 01.02.02 |
| 9 | 1.1.2.3 | DEMOLICION, REMOCION Y RASQUETEO | 3d | 2019-10-12 | 2019-10-15 |  | 127d | 0d |  | 01.02.03 |
| 10 | 1.1.3 | **MOVIMIENTO DE TIERRAS** | 24d | 2019-10-10 | 2019-11-03 |  | 0d |  |  | 01.03 |
| 11 | 1.1.3.1 | EXPLANACIONES (CORTE Y RELLENO) | 18d | 2019-10-15 | 2019-11-02 | 9 | 127d |  |  | 01.03.01 |
| 12 | 1.1.3.2 | CORTE Y EXCAVACION | 12d | 2019-10-10 | 2019-10-22 |  | 0d |  |  | 01.03.02 |
| 13 | 1.1.3.3 | RELLENO | 10d | 2019-10-16 | 2019-10-26 | 12SS+6d | 126d | 0d | start no earlier than 2010-11-15 | 01.03.03 |
| 14 | 1.1.3.4 | CONFORMACION,NIVELACION Y REFINE | 17d | 2019-10-17 | 2019-11-03 | 13SS+1d | 126d |  | start no earlier than 2010-11-16 | 01.03.04 |
| 15 | 1.1.3.5 | ACARREO Y ELIMINACION DE MATERIAL | 21d | 2019-10-13 | 2019-11-03 | 12SS+3d | 126d |  | start no earlier than 2010-11-12 | 01.03.05 |
| 16 | 1.1.4 | **CONCRETO SIMPLE** | 14d | 2019-10-16 | 2019-10-30 |  | 130d |  |  | 01.04 |
| 17 | 1.1.4.1 | SOLADO | 13d | 2019-10-17 | 2019-10-30 | 12SS+7d | 130d |  | start no earlier than 2010-11-16 | 01.04.01 |
| 18 | 1.1.4.2 | FALSO PISO | 13d | 2019-10-16 | 2019-10-29 | 22SS+3d | 131d |  | start no earlier than 2010-11-28 | 01.04.02 |
| 19 | 1.1.4.3 | CIMIENTO | 13d | 2019-10-17 | 2019-10-30 | 12SS+7d | 130d |  | start no earlier than 2010-11-16 | 01.04.03 |
| 20 | 1.1.4.4 | DADOS | 8d | 2019-10-17 | 2019-10-25 | 12SS+7d | 135d |  |  | 01.04.04 |
| 21 | 1.1.5 | **CONCRETO ARMADO** | 83d | 2019-10-13 | 2020-01-04 |  | 0d |  |  | 01.05 |
| 22 | 1.1.5.1 | SOBRECIMIENTO | 20d | 2019-10-13 | 2019-11-02 | 12SS+3d | 64d | 0d | start no earlier than 2010-11-23 | 01.05.01 |
| 23 | 1.1.5.2 | ZAPATAS | 30d | 2019-10-13 | 2019-11-12 | 12SS+3d | 117d |  | start no earlier than 2010-11-18 | 01.05.02 |
| 24 | 1.1.5.3 | VIGAS DE CIMENTACION | 30d | 2019-10-13 | 2019-11-12 | 12SS+3d | 117d |  | start no earlier than 2010-11-18 | 01.05.04 |
| 25 | 1.1.5.4 | COLUMNAS | 70d | 2019-10-13 | 2019-12-22 | 12SS+3d | 0d |  | start no earlier than 2010-11-19 | 01.05.05 |
| 26 | 1.1.5.5 | PLATEA DE CIMENTACION | 70d | 2019-10-13 | 2019-12-22 | 12SS+3d | 0d |  | start no earlier than 2010-11-19 | 01.05.06 |
| 27 | 1.1.5.6 | VIGAS | 70d | 2019-10-24 | 2020-01-02 | 26SS+11d, 25SS+11d | 0d |  | start no earlier than 2010-11-27 | 01.05.07 |
| 28 | 1.1.5.7 | LOSAS ALIGERADAS | 70d | 2019-10-24 | 2020-01-02 | 27SS | 0d |  | start no earlier than 2010-11-27 | 01.05.08 |
| 29 | 1.1.5.8 | ESCALERAS | 81d | 2019-10-15 | 2020-01-04 | 22SS+2d | 64d |  | start no earlier than 2010-11-26 | 01.05.09 |
| 30 | 1.1.5.9 | COLUMNETAS Y SOLERAS | 81d | 2019-10-15 | 2020-01-04 | 22SS+2d | 64d | 0d | start no earlier than 2010-11-26 | 01.05.10 |
| 31 | 1.1.5.10 | LOSA MACISA | 33d | 2019-11-14 | 2019-12-17 | 30SS+30d | 82d |  | start no earlier than 2011-01-01 | 01.05.11 |
| 32 | 1.1.5.11 | CISTERNA | 5d | 2019-10-13 | 2019-10-18 | 25SS | 142d |  | start no earlier than 2011-01-15 | 01.05.12 |
| 33 | 1.1.5.12 | TANQUE ELEVADO | 2d | 2019-10-13 | 2019-10-15 | 25SS | 145d |  | start no earlier than 2011-01-15 | 01.05.13 |
| 34 | 1.1.5.13 | BANCAS DE CONCRETO | 10d | 2019-10-13 | 2019-10-23 | 25SS | 137d |  | start no earlier than 2011-01-15 | 01.05.14 |
| 35 | 1.1.5.14 | JARDINERAS DE CONCRETO | 10d | 2019-10-13 | 2019-10-23 | 25SS | 127d | 0d | start no earlier than 2011-01-15 | 01.05.15 |
| 36 | 1.1.5.15 | CANALETAS CON REJILLA | 10d | 2019-10-23 | 2019-11-02 | 35 | 127d |  |  | 01.05.16 |
| 37 | 1.1.6 | ESTRUCTURAS METALICAS | 29d | 2019-12-22 | 2020-01-20 | 25 | 48d |  |  | 01.06 |

| ID | WBS | Task | Duration | Start | Finish | Predecessors | Total slack | Free slack | Constraint | Text1 |
| --- | --- | --- | --- | --- | --- | --- | --- | --- | --- | --- |
| 38 | 1.1.7 | **MOVILIZACION Y DESMOVILIZACION DE EQUIPO** | 6d | 2019-10-10 | 2019-10-16 |  | 144d |  |  | 01.07 |
| 39 | 1.1.7.1 | MOVILIZACION DE EQUIPO | 6d | 2019-10-10 | 2019-10-16 |  | 144d |  |  | 01.07.01 |
| 40 | 1.1.8 | **MITIGACION AMBIENTAL** | 80d | 2019-10-12 | 2019-12-31 |  | 68d |  |  | 01.08 |
| 41 | 1.1.8.1 | RIEGO DE TERRENO, MATERIAL EXCAVADO Y AGREGADOS | 80d | 2019-10-12 | 2019-12-31 | 5 | 68d |  | start no earlier than 2010-11-01 | 01.08.01 |
| 42 | 1.1.8.2 | PREVENCION DE DAÑOS - DERRAME DE COMBUSTIBLES | 80d | 2019-10-12 | 2019-12-31 | 5 | 68d |  | start no earlier than 2010-11-01 | 01.08.02 |
| 43 | 1.2 | **ARQUITECTURA** | 145d | 2019-10-12 | 2020-03-05 |  | 3d |  |  | 02 |
| 44 | 1.2.1 | MUROS Y TABIQUES DE ALBAÑILERIA | 103d | 2019-10-20 | 2020-01-31 | 26SS+7d, 25SS+7d | 37d |  | start no earlier than 2010-11-23 | 02.01 |
| 45 | 1.2.2 | REVOQUES Y REVESTIMIENTOS | 50d | 2019-11-28 | 2020-01-17 | 47SS+10d | 4d | 0d | start no earlier than 2011-01-09 | 02.02 |
| 46 | 1.2.3 | CIELORRASOS | 70d | 2019-11-20 | 2020-01-29 | 28SS+27d | 39d |  | start no earlier than 2010-12-24 | 02.03 |
| 47 | 1.2.4 | PISOS Y PAVIMENTOS | 70d | 2019-11-18 | 2020-01-27 | 28SS+25d | 0d |  | start no earlier than 2010-12-27 | 02.04 |
| 48 | 1.2.5 | ZOCALOS Y CONTRAZOCALOS | 30d | 2019-12-05 | 2020-01-04 | 47SS+17d | 64d |  | start no earlier than 2019-10-10 | 02.05 |
| 49 | 1.2.6 | COBERTURAS | 30d | 2020-01-02 | 2020-02-01 | 45SS+35d | 36d |  | start no earlier than 2011-01-31 | 02.06 |
| 50 | 1.2.7 | CARPINTERIA DE MADERA | 30d | 2020-01-27 | 2020-02-26 | 47 | 11d |  | start no earlier than 2010-11-06 | 02.07 |
| 51 | 1.2.8 | CARPINTERIA METALICA Y HERRERÍA | 40d | 2020-01-23 | 2020-03-03 | 54SS+6d | 5d | 0d | start no earlier than 2011-02-19 | 02.08 |
| 52 | 1.2.9 | VENTANAS DE ALUMINIO CON PROTECTOR, CRISTAL Y VIDRIOS | 40d | 2020-01-23 | 2020-03-03 | 54SS+6d | 5d |  | start no earlier than 2011-02-19 | 02.09 |
| 53 | 1.2.10 | CERRAJERIA | 40d | 2020-01-23 | 2020-03-03 | 51SS | 5d |  | start no earlier than 2011-02-26 | 02.10 |
| 54 | 1.2.11 | PINTURA | 30d | 2020-01-17 | 2020-02-16 | 45 | 5d | 0d |  | 02.11 |
| 55 | 1.2.12 | JUNTAS | 13d | 2020-01-27 | 2020-02-09 | 47 | 28d |  | start no earlier than 2011-01-20 | 02.12 |
| 56 | 1.2.13 | JUEGOS INFANTILES | 3d | 2020-02-16 | 2020-02-19 | 54 | 18d |  |  | 02.13 |
| 57 | 1.2.14 | VARIOS | 145d | 2019-10-12 | 2020-03-05 | 5 | 3d |  | start no earlier than 2011-02-04 | 02.14 |
| 58 | 1.3 | **INSTALACIONES SANITARIAS** | 18d | 2020-01-27 | 2020-02-14 |  | 4d | 0d |  | 03 |
| 59 | 1.3.1 | MOVIMIENTO DE TIERRAS | 5d | 2020-01-27 | 2020-02-01 | 45SS+60d | 9d | 5d |  | 03.01 |
| 60 | 1.3.2 | SISTEMA DE AGUA POTABLE EXTERIOR | 10d | 2020-01-27 | 2020-02-06 | 45SS+60d | 4d | 0d |  | 03.02 |
| 61 | 1.3.3 | SISTEMA DE RIEGO | 3d | 2020-02-06 | 2020-02-09 | 60, 59 | 4d | 0d |  | 03.03 |
| 62 | 1.3.4 | SISTEMA DE DESAGUE EXTERIOR | 10d | 2020-01-27 | 2020-02-06 | 45SS+60d | 12d |  |  | 03.04 |
| 63 | 1.3.5 | PRUEBA HIDRAULICA DE CISTERNA, TANQUE Y SISTEMA DE BOMBEO | 2d | 2020-02-09 | 2020-02-11 | 61 | 7d |  |  | 03.05 |
| 64 | 1.3.6 | APARATOS SANITARIOS Y ACCESORIOS | 5d | 2020-02-09 | 2020-02-14 | 61 | 4d | 0d |  | 03.06 |
| 65 | 1.3.7 | INSTALACIONES SANITARIAS DE DESAGUE | 10d | 2020-01-27 | 2020-02-06 | 45SS+60d | 7d | 0d |  | 03.07 |
| 66 | 1.3.8 | INSTALACIONES SANITARIAS DE AGUA | 10d | 2020-01-27 | 2020-02-06 | 45SS+60d | 12d |  |  | 03.08 |
| 67 | 1.3.9 | TUBERIAS Y ACCESORIOS TANQUE ELEVADO | 3d | 2020-02-06 | 2020-02-09 | 65 | 9d |  |  | 03.09 |
| 68 | 1.3.10 | SISTEMA DE DRENAJE PLUVIAL | 5d | 2020-02-06 | 2020-02-11 | 65 | 7d |  |  | 03.10 |
| 69 | 1.3.11 | RECONEXION A LAS REDES EXISTENTES | 2d | 2020-02-06 | 2020-02-08 | 65 | 10d |  |  | 03.11 |

| ID | WBS | Task | Duration | Start | Finish | Predecessors | Total slack | Free slack | Constraint | Text1 |
| --- | --- | --- | --- | --- | --- | --- | --- | --- | --- | --- |
| 70 | 1.4 | **INSTALACIONES ELECTRICAS** | 19d | 2020-02-14 | 2020-03-04 | 58 | 4d |  |  | 04 |
| 71 | 1.4.1 | EXCAVACION DE ZANJAS PARA CABLES ALIMENTADORES | 5d | 2020-02-14 | 2020-02-19 | 64 | 4d | 0d | start no earlier than 2011-03-02 | 04.01 |
| 72 | 1.4.2 | RELLLENO Y COMPACTACION MANUAL DE ZANJAS CON MATERIAL PROPIO | 10d | 2020-02-14 | 2020-02-24 |  | 13d |  | start no earlier than 2011-02-27 | 04.02 |
| 73 | 1.4.3 | SUMINISTRO E INSTALACION DE TABLEROS DE DISTRIBUCION ELECTRICO | 5d | 2020-02-20 | 2020-02-25 | 71SS+6d | 12d |  | start no earlier than 2011-03-05 | 04.03 |
| 74 | 1.4.4 | SUMINISTRO E INSTALACION DE CABLES Y CONDUCTORES | 6d | 2020-02-18 | 2020-02-24 | 71SS+4d | 4d | 0d |  | 04.04 |
| 75 | 1.4.5 | SUMINISTRO E INSTALACION DE TUBERIA PVC SAP (INCLUYE ACCESORIOS) | 6d | 2020-02-26 | 2020-03-03 | 74SS+8d | 5d |  | start no earlier than 2011-03-21 | 04.05 |
| 76 | 1.4.6 | SUMINISTRO E INSTALACION DE INTERRUPTORES (INC. ACCESORIOS ELECTRICOS | 6d | 2020-02-24 | 2020-03-01 | 74 | 7d |  |  | 04.06 |
| 77 | 1.4.7 | SUMINISTRO E INSTALACION DE TOMACORRIENTES (INC. ACCESORIOS ELECTRICOS) | 6d | 2020-02-24 | 2020-03-01 | 74 | 7d |  |  | 04.07 |
| 78 | 1.4.8 | SUMINISTRO E INSTALACION DE CAJAS ELECTRICAS | 5d | 2020-02-24 | 2020-02-29 | 74 | 4d | 0d |  | 04.08 |
| 79 | 1.4.9 | SUMINISTRO E INSTALACION DE ALUMBRADO DE EMERGENCIA (INCL ACCESOR ELECTRICOS) | 3d | 2020-02-20 | 2020-02-23 | 71SS+6d | 14d |  | start no earlier than 2011-03-05 | 04.09 |
| 80 | 1.4.10 | SUMINISTRO E INSTALACION DE ARETEFACTOS DE ILUMINACION | 3d | 2020-02-18 | 2020-02-21 | 71SS+4d | 7d | 0d |  | 04.10 |
| 81 | 1.4.11 | SUMINISTRO E INSTALACION DE PUESTA A TIERRA | 4d | 2020-02-26 | 2020-03-01 | 80SS+8d | 7d |  | start no earlier than 2011-03-21 | 04.11 |
| 82 | 1.4.12 | CONEXIÓN DE ACOMETIDA TRIFASICA A LA RED ELECTRICA DE CONCESIONARIA | 4d | 2020-02-29 | 2020-03-04 | 78 | 4d |  |  | 04.12 |
| 83 | 1.4.13 | PRUEBAS Y PUESTA EN SERVICIO | 3d | 2020-02-29 | 2020-03-03 | 78 | 5d |  |  | 04.13 |
| 84 | 1.4.14 | SUMINISTRO E INSTALACION DE RED DE DATA Y TELEFONIA PUBLICA PARA INTERNET DE ALTA VELOCIDAD | 3d | 2020-02-29 | 2020-03-03 | 78 | 5d |  |  | 04.14 |
| 85 | 1.4.15 | SUMINISTRO E INSTALACION DE VENTILADORES DE TECHO Y PARED | 15d | 2020-02-14 | 2020-02-29 | 58SS | 7d | 0d |  | 04.15 |
| 86 | 1.4.16 | SUMINISTRO E INSTALACION DE EQUIPAMIENTOS Y ACCESORIOS | 1d | 2020-02-29 | 2020-03-01 | 85 | 7d |  |  |  |
| 87 | 1.5 | **MOBILIARIO Y EQUIPAMIENTO** | 11d | 2020-02-26 | 2020-03-08 |  | 0d |  |  | 05 |
| 88 | 1.5.1 | MOBILIARIO Y EQUIPAMIENTO | 11d | 2020-02-26 | 2020-03-08 | 47FS+30d | 0d |  |  | 05.01 |
